# Gestão de Competências - Final

Schedule from MS Project, 2022-04-11 to 2023-06-06, status date 2022-04-18, costs in R$, A marks actual dates.

## Calendars

- Standard: Mon-Fri 08:00-12:00, 13:00-17:00; Sat-Sun off.

## Resources

| Resource | Rate |
| --- | --- |
| GP | 100 |
| Cliente |  |
| Patrocinador |  |
| Coordenador | 70 |
| Suprimentos | 50 |
| Equipe DC | 500 |
| FSW | 250000 |
| Suporte | 30 |
| Equipe CM |  |
| Consultoria CM | 800000 |
| Executivo | 120 |

## Schedule

| ID | WBS | Task | Type | Duration | Start | Finish | Predecessors | Complete | Remaining | Baseline start | Baseline finish | Baseline duration | Baseline 1 start | Baseline 1 finish | Total slack | Free slack | Constraint | Resources | Work | Actual work | Cost | Baseline cost | Actual cost | % Físico Planejado | Text2 |
| --- | --- | --- | --- | --- | --- | --- | --- | --- | --- | --- | --- | --- | --- | --- | --- | --- | --- | --- | --- | --- | --- | --- | --- | --- | --- |
| 1 | 1 | **Modelo de Gestão por Competências** |  | 301.88d | 2022-04-11 A | 2023-06-06 |  | 2% | 296.95d | 2022-04-11 | 2023-06-06 | 301.88d | 2022-04-11 | 2023-06-06 | 0d |  |  |  | 1574.1h | 38.77h | 14,657,115 | 14,657,815 | 3,637.5 | 0% |  |
| 2 | 1.1 | TAP Assinado | milestone | 0d | 2022-04-11 A | 2022-04-11 A |  | 100% |  | 2022-04-11 | 2022-04-11 | 0d | 2022-04-11 | 2022-04-11 |  |  |  |  |  |  |  |  |  | 0% |  |
| 3 | 1.2 | **Gerenciamento** |  | 300.88d | 2022-04-12 A | 2023-06-06 |  | 3% | 290.37d | 2022-04-11 | 2023-06-06 | 301.88d | 2022-04-11 | 2023-06-06 | 0d |  |  |  | 324h | 26.07h | 19,280 | 19,680 | 2,607.5 | 23% |  |
| 4 | 1.2.1 | **Planejamento** |  | 17d | 2022-04-12 A | 2022-05-05 |  | 16% | 14.22d | 2022-04-11 | 2022-05-02 | 15d | 2022-04-11 | 2022-05-02 | 215.88d |  |  |  | 196h | 26.07h | 11,600 | 12,000 | 2,607.5 | 39% |  |
| 5 | 1.2.1.1 | Elaborar plano de projeto |  | 12d | 2022-04-12 A | 2022-04-28 | 2 | 30% | 8.4d | 2022-04-11 | 2022-04-25 | 10d | 2022-04-11 | 2022-04-25 | 215.88d | 0d |  | GP | 85h | 26.07h | 8,500 | 8,000 | 2,607.5 | 58% |  |
| 6 | 1.2.1.2 | Homologar plano de projeto |  | 5d | 2022-04-28 | 2022-05-05 | 5 |  |  | 2022-04-25 | 2022-05-02 | 5d | 2022-04-25 | 2022-05-02 | 215.88d | 0d |  | Cliente; Patrocinador | 80h |  |  |  |  | 0% |  |
| 7 | 1.2.1.3 | Ajustar plano de projeto |  | 5d | 2022-04-28 | 2022-05-05 | 6FF |  |  | 2022-04-25 | 2022-05-02 | 5d | 2022-04-25 | 2022-05-02 | 215.88d | 0d |  | GP | 31h |  | 3,100 | 4,000 |  | 0% | [Digitar Nome da Coluna] |
| 8 | 1.2.1.4 | Plano de projeto elaborado | milestone | 0d | 2022-05-05 | 2022-05-05 | 7 |  |  | 2022-05-02 | 2022-05-02 | 0d | 2022-05-02 | 2022-05-02 | 215.88d | 0d |  |  |  |  |  |  |  | 0% |  |
| 9 | 1.2.2 | **Monitoramento e Controle** |  | 291.12d | 2022-04-18 | 2023-05-30 |  |  |  | 2022-04-18 | 2023-05-30 | 291.12d | 2022-04-18 | 2023-05-30 | 5.75d |  |  |  |  |  |  |  |  | 0% |  |
| 10 | 1.2.2.1 | **Realizar medição do projeto** |  | 291d | 2022-04-18 | 2023-05-30 |  |  |  | 2022-04-18 | 2023-05-30 | 291d | 2022-04-18 | 2023-05-30 | 5.88d |  |  |  |  |  |  |  |  | 0% |  |
| 11 | 1.2.2.1.1 | Realizar medição do projeto 1 |  | 3.33d | 2022-04-18 | 2022-04-21 |  |  |  | 2022-04-18 | 2022-04-21 | 3.33d | 2022-04-18 | 2022-04-21 | 293.54d |  | start no earlier than 2022-04-18 |  |  |  |  |  |  | 0% |  |
| 12 | 1.2.2.1.2 | Realizar medição do projeto 2 |  | 1d | 2022-04-25 | 2022-04-26 |  |  |  | 2022-04-25 | 2022-04-26 | 1d | 2022-04-25 | 2022-04-26 | 290.88d |  | start no earlier than 2022-04-25 |  |  |  |  |  |  | 0% |  |
| 13 | 1.2.2.1.3 | Realizar medição do projeto 3 |  | 1d | 2022-05-02 | 2022-05-03 |  |  |  | 2022-05-02 | 2022-05-03 | 1d | 2022-05-02 | 2022-05-03 | 285.88d |  | start no earlier than 2022-05-02 |  |  |  |  |  |  | 0% |  |
| 14 | 1.2.2.1.4 | Realizar medição do projeto 4 |  | 1d | 2022-05-09 | 2022-05-10 |  |  |  | 2022-05-09 | 2022-05-10 | 1d | 2022-05-09 | 2022-05-10 | 280.88d |  | start no earlier than 2022-05-09 |  |  |  |  |  |  | 0% |  |
| 15 | 1.2.2.1.5 | Realizar medição do projeto 5 |  | 1d | 2022-05-16 | 2022-05-17 |  |  |  | 2022-05-16 | 2022-05-17 | 1d | 2022-05-16 | 2022-05-17 | 275.88d |  | start no earlier than 2022-05-16 |  |  |  |  |  |  | 0% |  |
| 16 | 1.2.2.1.6 | Realizar medição do projeto 6 |  | 1d | 2022-05-23 | 2022-05-24 |  |  |  | 2022-05-23 | 2022-05-24 | 1d | 2022-05-23 | 2022-05-24 | 270.88d |  | start no earlier than 2022-05-23 |  |  |  |  |  |  | 0% |  |
| 17 | 1.2.2.1.7 | Realizar medição do projeto 7 |  | 1d | 2022-05-30 | 2022-05-31 |  |  |  | 2022-05-30 | 2022-05-31 | 1d | 2022-05-30 | 2022-05-31 | 265.88d |  | start no earlier than 2022-05-30 |  |  |  |  |  |  | 0% |  |
| 18 | 1.2.2.1.8 | Realizar medição do projeto 8 |  | 1d | 2022-06-06 | 2022-06-07 |  |  |  | 2022-06-06 | 2022-06-07 | 1d | 2022-06-06 | 2022-06-07 | 260.88d |  | start no earlier than 2022-06-06 |  |  |  |  |  |  | 0% |  |
| 19 | 1.2.2.1.9 | Realizar medição do projeto 9 |  | 1d | 2022-06-13 | 2022-06-14 |  |  |  | 2022-06-13 | 2022-06-14 | 1d | 2022-06-13 | 2022-06-14 | 255.88d |  | start no earlier than 2022-06-13 |  |  |  |  |  |  | 0% |  |
| 20 | 1.2.2.1.10 | Realizar medição do projeto 10 |  | 1d | 2022-06-20 | 2022-06-21 |  |  |  | 2022-06-20 | 2022-06-21 | 1d | 2022-06-20 | 2022-06-21 | 250.88d |  | start no earlier than 2022-06-20 |  |  |  |  |  |  | 0% |  |
| 21 | 1.2.2.1.11 | Realizar medição do projeto 11 |  | 1d | 2022-06-27 | 2022-06-28 |  |  |  | 2022-06-27 | 2022-06-28 | 1d | 2022-06-27 | 2022-06-28 | 245.88d |  | start no earlier than 2022-06-27 |  |  |  |  |  |  | 0% |  |
| 22 | 1.2.2.1.12 | Realizar medição do projeto 12 |  | 1d | 2022-07-04 | 2022-07-05 |  |  |  | 2022-07-04 | 2022-07-05 | 1d | 2022-07-04 | 2022-07-05 | 240.88d |  | start no earlier than 2022-07-04 |  |  |  |  |  |  | 0% |  |
| 23 | 1.2.2.1.13 | Realizar medição do projeto 13 |  | 1d | 2022-07-11 | 2022-07-12 |  |  |  | 2022-07-11 | 2022-07-12 | 1d | 2022-07-11 | 2022-07-12 | 235.88d |  | start no earlier than 2022-07-11 |  |  |  |  |  |  | 0% |  |
| 24 | 1.2.2.1.14 | Realizar medição do projeto 14 |  | 1d | 2022-07-18 | 2022-07-19 |  |  |  | 2022-07-18 | 2022-07-19 | 1d | 2022-07-18 | 2022-07-19 | 230.88d |  | start no earlier than 2022-07-18 |  |  |  |  |  |  | 0% |  |
| 25 | 1.2.2.1.15 | Realizar medição do projeto 15 |  | 1d | 2022-07-25 | 2022-07-26 |  |  |  | 2022-07-25 | 2022-07-26 | 1d | 2022-07-25 | 2022-07-26 | 225.88d |  | start no earlier than 2022-07-25 |  |  |  |  |  |  | 0% |  |
| 26 | 1.2.2.1.16 | Realizar medição do projeto 16 |  | 1d | 2022-08-01 | 2022-08-02 |  |  |  | 2022-08-01 | 2022-08-02 | 1d | 2022-08-01 | 2022-08-02 | 220.88d |  | start no earlier than 2022-08-01 |  |  |  |  |  |  | 0% |  |
| 27 | 1.2.2.1.17 | Realizar medição do projeto 17 |  | 1d | 2022-08-08 | 2022-08-09 |  |  |  | 2022-08-08 | 2022-08-09 | 1d | 2022-08-08 | 2022-08-09 | 215.88d |  | start no earlier than 2022-08-08 |  |  |  |  |  |  | 0% |  |
| 28 | 1.2.2.1.18 | Realizar medição do projeto 18 |  | 1d | 2022-08-15 | 2022-08-16 |  |  |  | 2022-08-15 | 2022-08-16 | 1d | 2022-08-15 | 2022-08-16 | 210.88d |  | start no earlier than 2022-08-15 |  |  |  |  |  |  | 0% |  |
| 29 | 1.2.2.1.19 | Realizar medição do projeto 19 |  | 1d | 2022-08-22 | 2022-08-23 |  |  |  | 2022-08-22 | 2022-08-23 | 1d | 2022-08-22 | 2022-08-23 | 205.88d |  | start no earlier than 2022-08-22 |  |  |  |  |  |  | 0% |  |
| 30 | 1.2.2.1.20 | Realizar medição do projeto 20 |  | 1d | 2022-08-29 | 2022-08-30 |  |  |  | 2022-08-29 | 2022-08-30 | 1d | 2022-08-29 | 2022-08-30 | 200.88d |  | start no earlier than 2022-08-29 |  |  |  |  |  |  | 0% |  |
| 31 | 1.2.2.1.21 | Realizar medição do projeto 21 |  | 1d | 2022-09-05 | 2022-09-06 |  |  |  | 2022-09-05 | 2022-09-06 | 1d | 2022-09-05 | 2022-09-06 | 195.88d |  | start no earlier than 2022-09-05 |  |  |  |  |  |  | 0% |  |
| 32 | 1.2.2.1.22 | Realizar medição do projeto 22 |  | 1d | 2022-09-12 | 2022-09-13 |  |  |  | 2022-09-12 | 2022-09-13 | 1d | 2022-09-12 | 2022-09-13 | 190.88d |  | start no earlier than 2022-09-12 |  |  |  |  |  |  | 0% |  |
| 33 | 1.2.2.1.23 | Realizar medição do projeto 23 |  | 1d | 2022-09-19 | 2022-09-20 |  |  |  | 2022-09-19 | 2022-09-20 | 1d | 2022-09-19 | 2022-09-20 | 185.88d |  | start no earlier than 2022-09-19 |  |  |  |  |  |  | 0% |  |
| 34 | 1.2.2.1.24 | Realizar medição do projeto 24 |  | 1d | 2022-09-26 | 2022-09-27 |  |  |  | 2022-09-26 | 2022-09-27 | 1d | 2022-09-26 | 2022-09-27 | 180.88d |  | start no earlier than 2022-09-26 |  |  |  |  |  |  | 0% |  |
| 35 | 1.2.2.1.25 | Realizar medição do projeto 25 |  | 1d | 2022-10-03 | 2022-10-04 |  |  |  | 2022-10-03 | 2022-10-04 | 1d | 2022-10-03 | 2022-10-04 | 175.88d |  | start no earlier than 2022-10-03 |  |  |  |  |  |  | 0% |  |
| 36 | 1.2.2.1.26 | Realizar medição do projeto 26 |  | 1d | 2022-10-10 | 2022-10-11 |  |  |  | 2022-10-10 | 2022-10-11 | 1d | 2022-10-10 | 2022-10-11 | 170.88d |  | start no earlier than 2022-10-10 |  |  |  |  |  |  | 0% |  |
| 37 | 1.2.2.1.27 | Realizar medição do projeto 27 |  | 1d | 2022-10-17 | 2022-10-18 |  |  |  | 2022-10-17 | 2022-10-18 | 1d | 2022-10-17 | 2022-10-18 | 165.88d |  | start no earlier than 2022-10-17 |  |  |  |  |  |  | 0% |  |
| 38 | 1.2.2.1.28 | Realizar medição do projeto 28 |  | 1d | 2022-10-24 | 2022-10-25 |  |  |  | 2022-10-24 | 2022-10-25 | 1d | 2022-10-24 | 2022-10-25 | 160.88d |  | start no earlier than 2022-10-24 |  |  |  |  |  |  | 0% |  |
| 39 | 1.2.2.1.29 | Realizar medição do projeto 29 |  | 1d | 2022-10-31 | 2022-11-01 |  |  |  | 2022-10-31 | 2022-11-01 | 1d | 2022-10-31 | 2022-11-01 | 155.88d |  | start no earlier than 2022-10-31 |  |  |  |  |  |  | 0% |  |
| 40 | 1.2.2.1.30 | Realizar medição do projeto 30 |  | 1d | 2022-11-07 | 2022-11-08 |  |  |  | 2022-11-07 | 2022-11-08 | 1d | 2022-11-07 | 2022-11-08 | 150.88d |  | start no earlier than 2022-11-07 |  |  |  |  |  |  | 0% |  |
| 41 | 1.2.2.1.31 | Realizar medição do projeto 31 |  | 1d | 2022-11-14 | 2022-11-15 |  |  |  | 2022-11-14 | 2022-11-15 | 1d | 2022-11-14 | 2022-11-15 | 145.88d |  | start no earlier than 2022-11-14 |  |  |  |  |  |  | 0% |  |
| 42 | 1.2.2.1.32 | Realizar medição do projeto 32 |  | 1d | 2022-11-21 | 2022-11-22 |  |  |  | 2022-11-21 | 2022-11-22 | 1d | 2022-11-21 | 2022-11-22 | 140.88d |  | start no earlier than 2022-11-21 |  |  |  |  |  |  | 0% |  |
| 43 | 1.2.2.1.33 | Realizar medição do projeto 33 |  | 1d | 2022-11-28 | 2022-11-29 |  |  |  | 2022-11-28 | 2022-11-29 | 1d | 2022-11-28 | 2022-11-29 | 135.88d |  | start no earlier than 2022-11-28 |  |  |  |  |  |  | 0% |  |
| 44 | 1.2.2.1.34 | Realizar medição do projeto 34 |  | 1d | 2022-12-05 | 2022-12-06 |  |  |  | 2022-12-05 | 2022-12-06 | 1d | 2022-12-05 | 2022-12-06 | 130.88d |  | start no earlier than 2022-12-05 |  |  |  |  |  |  | 0% |  |
| 45 | 1.2.2.1.35 | Realizar medição do projeto 35 |  | 1d | 2022-12-12 | 2022-12-13 |  |  |  | 2022-12-12 | 2022-12-13 | 1d | 2022-12-12 | 2022-12-13 | 125.88d |  | start no earlier than 2022-12-12 |  |  |  |  |  |  | 0% |  |
| 46 | 1.2.2.1.36 | Realizar medição do projeto 36 |  | 1d | 2022-12-19 | 2022-12-20 |  |  |  | 2022-12-19 | 2022-12-20 | 1d | 2022-12-19 | 2022-12-20 | 120.88d |  | start no earlier than 2022-12-19 |  |  |  |  |  |  | 0% |  |
| 47 | 1.2.2.1.37 | Realizar medição do projeto 37 |  | 1d | 2022-12-26 | 2022-12-27 |  |  |  | 2022-12-26 | 2022-12-27 | 1d | 2022-12-26 | 2022-12-27 | 115.88d |  | start no earlier than 2022-12-26 |  |  |  |  |  |  | 0% |  |
| 48 | 1.2.2.1.38 | Realizar medição do projeto 38 |  | 1d | 2023-01-02 | 2023-01-03 |  |  |  | 2023-01-02 | 2023-01-03 | 1d | 2023-01-02 | 2023-01-03 | 110.88d |  | start no earlier than 2023-01-02 |  |  |  |  |  |  | 0% |  |
| 49 | 1.2.2.1.39 | Realizar medição do projeto 39 |  | 1d | 2023-01-09 | 2023-01-10 |  |  |  | 2023-01-09 | 2023-01-10 | 1d | 2023-01-09 | 2023-01-10 | 105.88d |  | start no earlier than 2023-01-09 |  |  |  |  |  |  | 0% |  |
| 50 | 1.2.2.1.40 | Realizar medição do projeto 40 |  | 1d | 2023-01-16 | 2023-01-17 |  |  |  | 2023-01-16 | 2023-01-17 | 1d | 2023-01-16 | 2023-01-17 | 100.88d |  | start no earlier than 2023-01-16 |  |  |  |  |  |  | 0% |  |
| 51 | 1.2.2.1.41 | Realizar medição do projeto 41 |  | 1d | 2023-01-23 | 2023-01-24 |  |  |  | 2023-01-23 | 2023-01-24 | 1d | 2023-01-23 | 2023-01-24 | 95.88d |  | start no earlier than 2023-01-23 |  |  |  |  |  |  | 0% |  |
| 52 | 1.2.2.1.42 | Realizar medição do projeto 42 |  | 1d | 2023-01-30 | 2023-01-31 |  |  |  | 2023-01-30 | 2023-01-31 | 1d | 2023-01-30 | 2023-01-31 | 90.88d |  | start no earlier than 2023-01-30 |  |  |  |  |  |  | 0% |  |
| 53 | 1.2.2.1.43 | Realizar medição do projeto 43 |  | 1d | 2023-02-06 | 2023-02-07 |  |  |  | 2023-02-06 | 2023-02-07 | 1d | 2023-02-06 | 2023-02-07 | 85.88d |  | start no earlier than 2023-02-06 |  |  |  |  |  |  | 0% |  |
| 54 | 1.2.2.1.44 | Realizar medição do projeto 44 |  | 1d | 2023-02-13 | 2023-02-14 |  |  |  | 2023-02-13 | 2023-02-14 | 1d | 2023-02-13 | 2023-02-14 | 80.88d |  | start no earlier than 2023-02-13 |  |  |  |  |  |  | 0% |  |
| 55 | 1.2.2.1.45 | Realizar medição do projeto 45 |  | 1d | 2023-02-20 | 2023-02-21 |  |  |  | 2023-02-20 | 2023-02-21 | 1d | 2023-02-20 | 2023-02-21 | 75.88d |  | start no earlier than 2023-02-20 |  |  |  |  |  |  | 0% |  |
| 56 | 1.2.2.1.46 | Realizar medição do projeto 46 |  | 1d | 2023-02-27 | 2023-02-28 |  |  |  | 2023-02-27 | 2023-02-28 | 1d | 2023-02-27 | 2023-02-28 | 70.88d |  | start no earlier than 2023-02-27 |  |  |  |  |  |  | 0% |  |
| 57 | 1.2.2.1.47 | Realizar medição do projeto 47 |  | 1d | 2023-03-06 | 2023-03-07 |  |  |  | 2023-03-06 | 2023-03-07 | 1d | 2023-03-06 | 2023-03-07 | 65.88d |  | start no earlier than 2023-03-06 |  |  |  |  |  |  | 0% |  |
| 58 | 1.2.2.1.48 | Realizar medição do projeto 48 |  | 1d | 2023-03-13 | 2023-03-14 |  |  |  | 2023-03-13 | 2023-03-14 | 1d | 2023-03-13 | 2023-03-14 | 60.88d |  | start no earlier than 2023-03-13 |  |  |  |  |  |  | 0% |  |
| 59 | 1.2.2.1.49 | Realizar medição do projeto 49 |  | 1d | 2023-03-20 | 2023-03-21 |  |  |  | 2023-03-20 | 2023-03-21 | 1d | 2023-03-20 | 2023-03-21 | 55.88d |  | start no earlier than 2023-03-20 |  |  |  |  |  |  | 0% |  |
| 60 | 1.2.2.1.50 | Realizar medição do projeto 50 |  | 1d | 2023-03-27 | 2023-03-28 |  |  |  | 2023-03-27 | 2023-03-28 | 1d | 2023-03-27 | 2023-03-28 | 50.88d |  | start no earlier than 2023-03-27 |  |  |  |  |  |  | 0% |  |
| 61 | 1.2.2.1.51 | Realizar medição do projeto 51 |  | 1d | 2023-04-03 | 2023-04-04 |  |  |  | 2023-04-03 | 2023-04-04 | 1d | 2023-04-03 | 2023-04-04 | 45.88d |  | start no earlier than 2023-04-03 |  |  |  |  |  |  | 0% |  |
| 62 | 1.2.2.1.52 | Realizar medição do projeto 52 |  | 1d | 2023-04-10 | 2023-04-11 |  |  |  | 2023-04-10 | 2023-04-11 | 1d | 2023-04-10 | 2023-04-11 | 40.88d |  | start no earlier than 2023-04-10 |  |  |  |  |  |  | 0% |  |
| 63 | 1.2.2.1.53 | Realizar medição do projeto 53 |  | 1d | 2023-04-17 | 2023-04-18 |  |  |  | 2023-04-17 | 2023-04-18 | 1d | 2023-04-17 | 2023-04-18 | 35.88d |  | start no earlier than 2023-04-17 |  |  |  |  |  |  | 0% |  |
| 64 | 1.2.2.1.54 | Realizar medição do projeto 54 |  | 1d | 2023-04-24 | 2023-04-25 |  |  |  | 2023-04-24 | 2023-04-25 | 1d | 2023-04-24 | 2023-04-25 | 30.88d |  | start no earlier than 2023-04-24 |  |  |  |  |  |  | 0% |  |
| 65 | 1.2.2.1.55 | Realizar medição do projeto 55 |  | 1d | 2023-05-01 | 2023-05-02 |  |  |  | 2023-05-01 | 2023-05-02 | 1d | 2023-05-01 | 2023-05-02 | 25.88d |  | start no earlier than 2023-05-01 |  |  |  |  |  |  | 0% |  |
| 66 | 1.2.2.1.56 | Realizar medição do projeto 56 |  | 1d | 2023-05-08 | 2023-05-09 |  |  |  | 2023-05-08 | 2023-05-09 | 1d | 2023-05-08 | 2023-05-09 | 20.88d |  | start no earlier than 2023-05-08 |  |  |  |  |  |  | 0% |  |
| 67 | 1.2.2.1.57 | Realizar medição do projeto 57 |  | 1d | 2023-05-15 | 2023-05-16 |  |  |  | 2023-05-15 | 2023-05-16 | 1d | 2023-05-15 | 2023-05-16 | 15.88d |  | start no earlier than 2023-05-15 |  |  |  |  |  |  | 0% |  |
| 68 | 1.2.2.1.58 | Realizar medição do projeto 58 |  | 1d | 2023-05-22 | 2023-05-23 |  |  |  | 2023-05-22 | 2023-05-23 | 1d | 2023-05-22 | 2023-05-23 | 10.88d |  | start no earlier than 2023-05-22 |  |  |  |  |  |  | 0% |  |
| 69 | 1.2.2.1.59 | Realizar medição do projeto 59 |  | 1d | 2023-05-29 | 2023-05-30 |  |  |  | 2023-05-29 | 2023-05-30 | 1d | 2023-05-29 | 2023-05-30 | 5.88d |  | start no earlier than 2023-05-29 |  |  |  |  |  |  | 0% |  |

| ID | WBS | Task | Duration | Start | Finish | Baseline start | Baseline finish | Baseline duration | Baseline 1 start | Baseline 1 finish | Total slack | Constraint | % Físico Planejado |
| --- | --- | --- | --- | --- | --- | --- | --- | --- | --- | --- | --- | --- | --- |
| 70 | 1.2.2.2 | **Realizar reunião de status report executivo** | 290.12d | 2022-04-19 | 2023-05-30 | 2022-04-19 | 2023-05-30 | 290.12d | 2022-04-19 | 2023-05-30 | 5.75d |  | 0% |
| 71 | 1.2.2.2.1 | Realizar reunião de status report executivo 1 | 1h | 2022-04-19 | 2022-04-19 | 2022-04-19 | 2022-04-19 | 1h | 2022-04-19 | 2022-04-19 | 295.75d | start no earlier than 2022-04-19 | 0% |
| 72 | 1.2.2.2.2 | Realizar reunião de status report executivo 2 | 1h | 2022-05-03 | 2022-05-03 | 2022-05-03 | 2022-05-03 | 1h | 2022-05-03 | 2022-05-03 | 285.75d | start no earlier than 2022-05-03 | 0% |
| 73 | 1.2.2.2.3 | Realizar reunião de status report executivo 3 | 1h | 2022-05-17 | 2022-05-17 | 2022-05-17 | 2022-05-17 | 1h | 2022-05-17 | 2022-05-17 | 275.75d | start no earlier than 2022-05-17 | 0% |
| 74 | 1.2.2.2.4 | Realizar reunião de status report executivo 4 | 1h | 2022-05-31 | 2022-05-31 | 2022-05-31 | 2022-05-31 | 1h | 2022-05-31 | 2022-05-31 | 265.75d | start no earlier than 2022-05-31 | 0% |
| 75 | 1.2.2.2.5 | Realizar reunião de status report executivo 5 | 1h | 2022-06-14 | 2022-06-14 | 2022-06-14 | 2022-06-14 | 1h | 2022-06-14 | 2022-06-14 | 255.75d | start no earlier than 2022-06-14 | 0% |
| 76 | 1.2.2.2.6 | Realizar reunião de status report executivo 6 | 1h | 2022-06-28 | 2022-06-28 | 2022-06-28 | 2022-06-28 | 1h | 2022-06-28 | 2022-06-28 | 245.75d | start no earlier than 2022-06-28 | 0% |
| 77 | 1.2.2.2.7 | Realizar reunião de status report executivo 7 | 1h | 2022-07-12 | 2022-07-12 | 2022-07-12 | 2022-07-12 | 1h | 2022-07-12 | 2022-07-12 | 235.75d | start no earlier than 2022-07-12 | 0% |
| 78 | 1.2.2.2.8 | Realizar reunião de status report executivo 8 | 1h | 2022-07-26 | 2022-07-26 | 2022-07-26 | 2022-07-26 | 1h | 2022-07-26 | 2022-07-26 | 225.75d | start no earlier than 2022-07-26 | 0% |
| 79 | 1.2.2.2.9 | Realizar reunião de status report executivo 9 | 1h | 2022-08-09 | 2022-08-09 | 2022-08-09 | 2022-08-09 | 1h | 2022-08-09 | 2022-08-09 | 215.75d | start no earlier than 2022-08-09 | 0% |
| 80 | 1.2.2.2.10 | Realizar reunião de status report executivo 10 | 1h | 2022-08-23 | 2022-08-23 | 2022-08-23 | 2022-08-23 | 1h | 2022-08-23 | 2022-08-23 | 205.75d | start no earlier than 2022-08-23 | 0% |
| 81 | 1.2.2.2.11 | Realizar reunião de status report executivo 11 | 1h | 2022-09-06 | 2022-09-06 | 2022-09-06 | 2022-09-06 | 1h | 2022-09-06 | 2022-09-06 | 195.75d | start no earlier than 2022-09-06 | 0% |
| 82 | 1.2.2.2.12 | Realizar reunião de status report executivo 12 | 1h | 2022-09-20 | 2022-09-20 | 2022-09-20 | 2022-09-20 | 1h | 2022-09-20 | 2022-09-20 | 185.75d | start no earlier than 2022-09-20 | 0% |
| 83 | 1.2.2.2.13 | Realizar reunião de status report executivo 13 | 1h | 2022-10-04 | 2022-10-04 | 2022-10-04 | 2022-10-04 | 1h | 2022-10-04 | 2022-10-04 | 175.75d | start no earlier than 2022-10-04 | 0% |
| 84 | 1.2.2.2.14 | Realizar reunião de status report executivo 14 | 1h | 2022-10-18 | 2022-10-18 | 2022-10-18 | 2022-10-18 | 1h | 2022-10-18 | 2022-10-18 | 165.75d | start no earlier than 2022-10-18 | 0% |
| 85 | 1.2.2.2.15 | Realizar reunião de status report executivo 15 | 1h | 2022-11-01 | 2022-11-01 | 2022-11-01 | 2022-11-01 | 1h | 2022-11-01 | 2022-11-01 | 155.75d | start no earlier than 2022-11-01 | 0% |
| 86 | 1.2.2.2.16 | Realizar reunião de status report executivo 16 | 1h | 2022-11-15 | 2022-11-15 | 2022-11-15 | 2022-11-15 | 1h | 2022-11-15 | 2022-11-15 | 145.75d | start no earlier than 2022-11-15 | 0% |
| 87 | 1.2.2.2.17 | Realizar reunião de status report executivo 17 | 1h | 2022-11-29 | 2022-11-29 | 2022-11-29 | 2022-11-29 | 1h | 2022-11-29 | 2022-11-29 | 135.75d | start no earlier than 2022-11-29 | 0% |
| 88 | 1.2.2.2.18 | Realizar reunião de status report executivo 18 | 1h | 2022-12-13 | 2022-12-13 | 2022-12-13 | 2022-12-13 | 1h | 2022-12-13 | 2022-12-13 | 125.75d | start no earlier than 2022-12-13 | 0% |
| 89 | 1.2.2.2.19 | Realizar reunião de status report executivo 19 | 1h | 2022-12-27 | 2022-12-27 | 2022-12-27 | 2022-12-27 | 1h | 2022-12-27 | 2022-12-27 | 115.75d | start no earlier than 2022-12-27 | 0% |
| 90 | 1.2.2.2.20 | Realizar reunião de status report executivo 20 | 1h | 2023-01-10 | 2023-01-10 | 2023-01-10 | 2023-01-10 | 1h | 2023-01-10 | 2023-01-10 | 105.75d | start no earlier than 2023-01-10 | 0% |
| 91 | 1.2.2.2.21 | Realizar reunião de status report executivo 21 | 1h | 2023-01-24 | 2023-01-24 | 2023-01-24 | 2023-01-24 | 1h | 2023-01-24 | 2023-01-24 | 95.75d | start no earlier than 2023-01-24 | 0% |
| 92 | 1.2.2.2.22 | Realizar reunião de status report executivo 22 | 1h | 2023-02-07 | 2023-02-07 | 2023-02-07 | 2023-02-07 | 1h | 2023-02-07 | 2023-02-07 | 85.75d | start no earlier than 2023-02-07 | 0% |
| 93 | 1.2.2.2.23 | Realizar reunião de status report executivo 23 | 1h | 2023-02-21 | 2023-02-21 | 2023-02-21 | 2023-02-21 | 1h | 2023-02-21 | 2023-02-21 | 75.75d | start no earlier than 2023-02-21 | 0% |
| 94 | 1.2.2.2.24 | Realizar reunião de status report executivo 24 | 1h | 2023-03-07 | 2023-03-07 | 2023-03-07 | 2023-03-07 | 1h | 2023-03-07 | 2023-03-07 | 65.75d | start no earlier than 2023-03-07 | 0% |
| 95 | 1.2.2.2.25 | Realizar reunião de status report executivo 25 | 1h | 2023-03-21 | 2023-03-21 | 2023-03-21 | 2023-03-21 | 1h | 2023-03-21 | 2023-03-21 | 55.75d | start no earlier than 2023-03-21 | 0% |
| 96 | 1.2.2.2.26 | Realizar reunião de status report executivo 26 | 1h | 2023-04-04 | 2023-04-04 | 2023-04-04 | 2023-04-04 | 1h | 2023-04-04 | 2023-04-04 | 45.75d | start no earlier than 2023-04-04 | 0% |
| 97 | 1.2.2.2.27 | Realizar reunião de status report executivo 27 | 1h | 2023-04-18 | 2023-04-18 | 2023-04-18 | 2023-04-18 | 1h | 2023-04-18 | 2023-04-18 | 35.75d | start no earlier than 2023-04-18 | 0% |
| 98 | 1.2.2.2.28 | Realizar reunião de status report executivo 28 | 1h | 2023-05-02 | 2023-05-02 | 2023-05-02 | 2023-05-02 | 1h | 2023-05-02 | 2023-05-02 | 25.75d | start no earlier than 2023-05-02 | 0% |
| 99 | 1.2.2.2.29 | Realizar reunião de status report executivo 29 | 1h | 2023-05-16 | 2023-05-16 | 2023-05-16 | 2023-05-16 | 1h | 2023-05-16 | 2023-05-16 | 15.75d | start no earlier than 2023-05-16 | 0% |
| 100 | 1.2.2.2.30 | Realizar reunião de status report executivo 30 | 1h | 2023-05-30 | 2023-05-30 | 2023-05-30 | 2023-05-30 | 1h | 2023-05-30 | 2023-05-30 | 5.75d | start no earlier than 2023-05-30 | 0% |

| ID | WBS | Task | Type | Duration | Start | Finish | Predecessors | Complete | Remaining | Baseline start | Baseline finish | Baseline duration | Baseline 1 start | Baseline 1 finish | Total slack | Free slack | Resources | Work | Actual work | Cost | Baseline cost | Actual cost | % Físico Planejado |
| --- | --- | --- | --- | --- | --- | --- | --- | --- | --- | --- | --- | --- | --- | --- | --- | --- | --- | --- | --- | --- | --- | --- | --- |
| 101 | 1.2.3 | **Encerramento** |  | 16d | 2023-05-16 | 2023-06-06 |  |  |  | 2023-05-16 | 2023-06-06 | 16d | 2023-05-16 | 2023-06-06 | 0d |  |  | 128h |  | 7,680 | 7,680 |  | 0% |
| 102 | 1.2.3.1 | Solicitar aceite final |  | 1d | 2023-05-16 | 2023-05-16 | 169 |  |  | 2023-05-16 | 2023-05-16 | 1d | 2023-05-16 | 2023-05-16 | 0d |  | Coordenador | 8h |  | 560 | 560 |  | 0% |
| 103 | 1.2.3.2 | Obter aceite final |  | 5d | 2023-05-17 | 2023-05-23 | 102 |  |  | 2023-05-17 | 2023-05-23 | 5d | 2023-05-17 | 2023-05-23 | 0d |  | Cliente | 40h |  |  |  |  | 0% |
| 104 | 1.2.3.3 | Preparar termo de encerramento |  | 3d | 2023-05-24 | 2023-05-26 | 103 |  |  | 2023-05-24 | 2023-05-26 | 3d | 2023-05-24 | 2023-05-26 | 0d |  | GP | 24h |  | 2,400 | 2,400 |  | 0% |
| 105 | 1.2.3.4 | Fechar lições aprendidas |  | 5d | 2023-05-29 | 2023-06-02 | 104 |  |  | 2023-05-29 | 2023-06-02 | 5d | 2023-05-29 | 2023-06-02 | 0d |  | Coordenador | 40h |  | 2,800 | 2,800 |  | 0% |
| 106 | 1.2.3.5 | Dar baixa no sistema DCVMO |  | 2d | 2023-06-05 | 2023-06-06 | 105 |  |  | 2023-06-05 | 2023-06-06 | 2d | 2023-06-05 | 2023-06-06 | 0d |  | Executivo | 16h |  | 1,920 | 1,920 |  | 0% |
| 107 | 1.2.3.6 | Projeto Encerrado | milestone | 0d | 2023-06-06 | 2023-06-06 | 106 |  |  | 2023-06-06 | 2023-06-06 | 0d | 2023-06-06 | 2023-06-06 | 0d |  |  |  |  |  |  |  | 0% |
| 108 | 1.3 | **Modelo** |  | 68d | 2022-05-05 | 2022-08-09 |  |  |  | 2022-05-02 | 2022-08-04 | 68d | 2022-05-02 | 2022-08-04 | 215.88d |  |  | 497h |  | 99,370 | 99,370 |  | 0% |
| 109 | 1.3.1 | **Contratação da Consultoria** |  | 45d | 2022-05-05 | 2022-07-07 |  |  |  | 2022-05-02 | 2022-07-04 | 45d | 2022-05-02 | 2022-07-04 | 215.88d |  |  | 313h |  | 17,450 | 17,450 |  | 0% |
| 110 | 1.3.1.1 | Divulgar RFP |  | 10d | 2022-05-05 | 2022-05-19 | 8 |  |  | 2022-05-02 | 2022-05-16 | 10d | 2022-05-02 | 2022-05-16 | 215.88d | 0d | Suprimentos | 41h |  | 2,050 | 2,050 |  | 0% |
| 111 | 1.3.1.2 | Receber propostas |  | 10d | 2022-05-19 | 2022-06-02 | 110 |  |  | 2022-05-16 | 2022-05-30 | 10d | 2022-05-16 | 2022-05-30 | 215.88d | 0d | Suprimentos | 40h |  | 2,000 | 2,000 |  | 0% |
| 112 | 1.3.1.3 | Avaliar propostas |  | 10d | 2022-06-02 | 2022-06-16 | 111 |  |  | 2022-05-30 | 2022-06-13 | 10d | 2022-05-30 | 2022-06-13 | 215.88d | 0d | Suprimentos | 76h |  | 3,800 | 3,800 |  | 0% |
| 113 | 1.3.1.4 | Selecionar fornecedor |  | 5d | 2022-06-16 | 2022-06-23 | 112 |  |  | 2022-06-13 | 2022-06-20 | 5d | 2022-06-13 | 2022-06-20 | 215.88d | 0d | Suprimentos; GP | 76h |  | 5,600 | 5,600 |  | 0% |
| 114 | 1.3.1.5 | Assinar contrato |  | 10d | 2022-06-23 | 2022-07-07 | 113 |  |  | 2022-06-20 | 2022-07-04 | 10d | 2022-06-20 | 2022-07-04 | 215.88d | 0d | Suprimentos | 80h |  | 4,000 | 4,000 |  | 0% |
| 115 | 1.3.1.6 | Fornecedor Contratado | milestone | 0d | 2022-07-07 | 2022-07-07 | 114 |  |  | 2022-07-04 | 2022-07-04 | 0d | 2022-07-04 | 2022-07-04 | 215.88d | 0d |  |  |  |  |  |  | 0% |
| 116 | 1.3.2 | **Levantamento de Requisitos** |  | 23d | 2022-07-07 | 2022-08-09 |  |  |  | 2022-07-04 | 2022-08-04 | 23d | 2022-07-04 | 2022-08-04 | 215.88d |  |  | 184h |  | 81,920 | 81,920 |  | 0% |
| 117 | 1.3.2.1 | Definir stakeholders |  | 1d | 2022-07-07 | 2022-07-08 | 115 |  |  | 2022-07-04 | 2022-07-05 | 1d | 2022-07-04 | 2022-07-05 | 215.88d | 0d | GP | 8h |  | 800 | 800 |  | 0% |
| 118 | 1.3.2.2 | Planejar agenda de levantamento |  | 2d | 2022-07-08 | 2022-07-12 | 117 |  |  | 2022-07-05 | 2022-07-07 | 2d | 2022-07-05 | 2022-07-07 | 215.88d | 0d | Coordenador | 16h |  | 1,120 | 1,120 |  | 0% |
| 119 | 1.3.2.3 | Levantar requisitos |  | 15d | 2022-07-12 | 2022-08-02 | 118 |  |  | 2022-07-07 | 2022-07-28 | 15d | 2022-07-07 | 2022-07-28 | 215.88d | 0d | Equipe DC | 120h |  | 60,000 | 60,000 |  | 0% |
| 120 | 1.3.2.4 | Consolidar requisitos |  | 5d | 2022-08-02 | 2022-08-09 | 119 |  |  | 2022-07-28 | 2022-08-04 | 5d | 2022-07-28 | 2022-08-04 | 215.88d |  | Equipe DC | 40h |  | 20,000 | 20,000 |  | 0% |
| 121 | 1.4 | **Sistema Informatizado** |  | 165.88d | 2022-04-11 A | 2022-11-28 |  | 2% | 162.3d | 2022-04-11 | 2022-11-28 | 165.88d | 2022-05-02 | 2022-11-28 | 136d |  |  | 593.1h | 12.7h | 124,865 | 125,165 | 1,030 | 0% |
| 122 | 1.4.1 | **Contratação da FSW** |  | 20.88d | 2022-05-05 | 2022-06-02 |  |  |  | 2022-05-02 | 2022-05-30 | 20.88d | 2022-05-02 | 2022-05-30 | 263d |  |  | 103.5h |  | 6,225 | 6,525 |  | 0% |
| 123 | 1.4.1.1 | Divulgar RFP FSW |  | 4.88d | 2022-05-05 | 2022-05-11 | 8 |  |  | 2022-05-02 | 2022-05-06 | 4.88d | 2022-05-02 | 2022-05-06 | 263d | 0d | Suprimentos | 20h |  | 1,000 | 1,000 |  | 0% |
| 124 | 1.4.1.2 | Receber propostas FSW |  | 5d | 2022-05-12 | 2022-05-18 | 123 |  |  | 2022-05-09 | 2022-05-13 | 5d | 2022-05-09 | 2022-05-13 | 263d | 0d | Suprimentos | 20h |  | 1,000 | 1,000 |  | 0% |
| 125 | 1.4.1.3 | Avaliar propostas FSW |  | 5d | 2022-05-19 | 2022-05-25 | 124 |  |  | 2022-05-16 | 2022-05-20 | 5d | 2022-05-16 | 2022-05-20 | 263d | 0d | Suprimentos | 19.5h |  | 975 | 975 |  | 0% |
| 126 | 1.4.1.4 | Selecionar fornecedor FSW |  | 3d | 2022-05-26 | 2022-05-30 | 125 |  |  | 2022-05-23 | 2022-05-25 | 3d | 2022-05-23 | 2022-05-25 | 263d | 0d | Suprimentos; GP | 32.5h |  | 2,675 | 2,975 |  | 0% |
| 127 | 1.4.1.5 | Assinar contrato FSW |  | 3d | 2022-05-31 | 2022-06-02 | 126 |  |  | 2022-05-26 | 2022-05-30 | 3d | 2022-05-26 | 2022-05-30 | 263d | 0d | Suprimentos | 11.5h |  | 575 | 575 |  | 0% |
| 128 | 1.4.1.6 | FSW Contratada | milestone | 0d | 2022-06-02 | 2022-06-02 | 127 |  |  | 2022-05-30 | 2022-05-30 | 0d | 2022-05-30 | 2022-05-30 | 263d | 0d |  |  |  |  |  |  | 0% |
| 129 | 1.2 | Projeto FSW autorizado | milestone | 0d | 2022-06-02 | 2022-06-02 | 128 |  |  | 2022-05-30 | 2022-05-30 | 0d |  |  | 263d |  |  |  |  |  |  |  | 0% |

| ID | WBS | Task | Type | Duration | Start | Finish | Predecessors | Complete | Remaining | Baseline start | Baseline finish | Baseline duration | Baseline 1 start | Baseline 1 finish | Total slack | Free slack | Resources | Work | Actual work | Cost | Baseline cost | Actual cost | % Físico Planejado |
| --- | --- | --- | --- | --- | --- | --- | --- | --- | --- | --- | --- | --- | --- | --- | --- | --- | --- | --- | --- | --- | --- | --- | --- |
| 130 | 1.4.2 | **Desenvolvimento** |  | 147.88d | 2022-04-11 A | 2022-11-02 |  | 3% | 144d | 2022-04-11 | 2022-11-02 | 147.88d | 2022-05-30 | 2022-11-02 | 154d | 0d |  | 265.6h | 12.7h | 17,920 | 17,920 | 1,030 | 5% |
| 131 | 1.4.2.1 | FSW - Desenvolver APP - Final |  | 112d | 2022-05-31 | 2022-11-02 |  |  |  | 2022-05-30 | 2022-11-02 | 112d |  |  | 154d |  |  | 168h |  | 8,400 | 8,400 |  | 0% |
| 132 | 1.4.2.2 | Fiscalizar FSW |  | 112d | 2022-04-11 A | 2022-09-14 |  | 5% | 106.12d | 2022-04-11 | 2022-09-14 | 112d | 2022-05-31 | 2022-11-02 | 35.88d |  | Coordenador [30%]; GP [10%] | 97.6h | 12.7h | 9,520 | 9,520 | 1,030 | 10% |
| 133 | 1.4.3 | **Instalação** |  | 18d | 2022-11-03 | 2022-11-28 |  |  |  | 2022-11-03 | 2022-11-28 | 18d | 2022-11-03 | 2022-11-28 | 0d |  |  | 224h |  | 100,720 | 100,720 |  | 0% |
| 134 | 1.4.3.1 | Instalar em produção |  | 5d | 2022-11-03 | 2022-11-09 | 130 |  |  | 2022-11-03 | 2022-11-09 | 5d | 2022-11-03 | 2022-11-09 | 0d |  | Equipe DC | 40h |  | 20,000 | 20,000 |  | 0% |
| 135 | 1.4.3.2 | Fazer testes em produção |  | 10d | 2022-11-10 | 2022-11-23 | 134 |  |  | 2022-11-10 | 2022-11-23 | 10d | 2022-11-10 | 2022-11-23 | 0d |  | Equipe DC | 80h |  | 40,000 | 40,000 |  | 0% |
| 136 | 1.4.3.3 | Ajustar instalação |  | 10d | 2022-11-10 | 2022-11-23 | 135FF |  |  | 2022-11-10 | 2022-11-23 | 10d | 2022-11-10 | 2022-11-23 | 0d |  | Equipe DC | 80h |  | 40,000 | 40,000 |  | 0% |
| 137 | 1.4.3.4 | Emitir aceite de produção |  | 3d | 2022-11-24 | 2022-11-28 | 136 |  |  | 2022-11-24 | 2022-11-28 | 3d | 2022-11-24 | 2022-11-28 | 0d |  | Suporte | 24h |  | 720 | 720 |  | 0% |
| 138 | 1.5 | **Change Management** |  | 104d | 2022-11-29 | 2023-04-21 |  |  |  | 2022-11-29 | 2023-04-21 | 104d | 2022-11-29 | 2023-04-21 | 0d |  |  |  |  | 9,600,000 | 9,600,000 |  | 0% |
| 139 | 1.5.1 | **Definição das Ações** |  | 15d | 2022-11-29 | 2022-12-19 |  |  |  | 2022-11-29 | 2022-12-19 | 15d | 2022-11-29 | 2022-12-19 | 0d |  |  |  |  | 2,400,000 | 2,400,000 |  | 0% |
| 140 | 1.5.1.1 | Plenejar ações de CM |  | 10d | 2022-11-29 | 2022-12-12 | 137 |  |  | 2022-11-29 | 2022-12-12 | 10d | 2022-11-29 | 2022-12-12 | 0d |  | Consultoria CM |  |  | 800,000 | 800,000 |  | 0% |
| 141 | 1.5.1.2 | Aprovar plano de ações de CM |  | 5d | 2022-12-13 | 2022-12-19 | 140 |  |  | 2022-12-13 | 2022-12-19 | 5d | 2022-12-13 | 2022-12-19 | 0d |  | Consultoria CM |  |  | 800,000 | 800,000 |  | 0% |
| 142 | 1.5.1.3 | Ajustar plano de ações de CM |  | 5d | 2022-12-13 | 2022-12-19 | 141FF |  |  | 2022-12-13 | 2022-12-19 | 5d | 2022-12-13 | 2022-12-19 | 0d |  | Consultoria CM |  |  | 800,000 | 800,000 |  | 0% |
| 143 | 1.5.2 | **Realização das Ações** |  | 27d | 2022-12-20 | 2023-01-25 |  |  |  | 2022-12-20 | 2023-01-25 | 27d | 2022-12-20 | 2023-01-25 | 0d |  |  |  |  | 2,400,000 | 2,400,000 |  | 0% |
| 144 | 1.5.2.1 | Realizar ações de CM |  | 20d | 2022-12-20 | 2023-01-16 | 142 |  |  | 2022-12-20 | 2023-01-16 | 20d | 2022-12-20 | 2023-01-16 | 0d |  | Consultoria CM |  |  | 800,000 | 800,000 |  | 0% |
| 145 | 1.5.2.2 | Gerar relatório das ações de CM |  | 5d | 2023-01-17 | 2023-01-23 | 144 |  |  | 2023-01-17 | 2023-01-23 | 5d | 2023-01-17 | 2023-01-23 | 0d |  | Consultoria CM |  |  | 800,000 | 800,000 |  | 0% |
| 146 | 1.5.2.3 | Divulgar ações realizadas |  | 2d | 2023-01-24 | 2023-01-25 | 145 |  |  | 2023-01-24 | 2023-01-25 | 2d | 2023-01-24 | 2023-01-25 | 0d |  | Consultoria CM |  |  | 800,000 | 800,000 |  | 0% |
| 147 | 1.5.3 | **Endomarketing** |  | 13d | 2023-01-26 | 2023-02-13 |  |  |  | 2023-01-26 | 2023-02-13 | 13d | 2023-01-26 | 2023-02-13 | 0d |  |  |  |  | 2,400,000 | 2,400,000 |  | 0% |
| 148 | 1.5.3.1 | Plenejar ações de ENDOMKT |  | 5d | 2023-01-26 | 2023-02-01 | 146 |  |  | 2023-01-26 | 2023-02-01 | 5d | 2023-01-26 | 2023-02-01 | 0d |  | Consultoria CM |  |  | 800,000 | 800,000 |  | 0% |
| 149 | 1.5.3.2 | Aprovar ações de ENDOMKT |  | 3d | 2023-02-02 | 2023-02-06 | 148 |  |  | 2023-02-02 | 2023-02-06 | 3d | 2023-02-02 | 2023-02-06 | 0d |  | Consultoria CM |  |  | 800,000 | 800,000 |  | 0% |
| 150 | 1.5.3.3 | Ajustar ações de ENDOMKT |  | 3d | 2023-02-02 | 2023-02-06 | 149FF |  |  | 2023-02-02 | 2023-02-06 | 3d | 2023-02-02 | 2023-02-06 | 0d |  | Consultoria CM |  |  | 800,000 | 800,000 |  | 0% |
| 151 | 1.5.3.4 | Realizar divulgação |  | 5d | 2023-02-07 | 2023-02-13 | 150 |  |  | 2023-02-07 | 2023-02-13 | 5d | 2023-02-07 | 2023-02-13 | 0d |  |  |  |  |  |  |  | 0% |
| 152 | 1.5.4 | **Capacitação no Novo Modelo** |  | 9d | 2023-04-11 | 2023-04-21 |  |  |  | 2023-04-11 | 2023-04-21 | 9d | 2023-04-11 | 2023-04-21 | 32d |  |  |  |  | 2,400,000 | 2,400,000 |  | 0% |
| 153 | 1.5.4.1 | Selecionar público |  | 2d | 2023-04-11 | 2023-04-12 | 164 |  |  | 2023-04-11 | 2023-04-12 | 2d | 2023-04-11 | 2023-04-12 | 32d | 0d | Consultoria CM |  |  | 800,000 | 800,000 |  | 0% |
| 154 | 1.5.4.2 | Treinar público |  | 5d | 2023-04-13 | 2023-04-19 | 153 |  |  | 2023-04-13 | 2023-04-19 | 5d | 2023-04-13 | 2023-04-19 | 32d | 0d | Consultoria CM |  |  | 800,000 | 800,000 |  | 0% |
| 155 | 1.5.4.3 | Emitir relatório de capacitação |  | 2d | 2023-04-20 | 2023-04-21 | 154 |  |  | 2023-04-20 | 2023-04-21 | 2d | 2023-04-20 | 2023-04-21 | 32d | 0d | Consultoria CM |  |  | 800,000 | 800,000 |  | 0% |
| 156 | 1.5.5 | CM Finalizado | milestone | 0d | 2023-04-21 | 2023-04-21 | 155 |  |  | 2023-04-21 | 2023-04-21 | 0d | 2023-04-21 | 2023-04-21 | 32d |  |  |  |  |  |  |  | 0% |

| ID | WBS | Task | Type | Duration | Start | Finish | Predecessors | Baseline start | Baseline finish | Baseline duration | Baseline 1 start | Baseline 1 finish | Total slack | Resources | Work | Cost | Baseline cost | % Físico Planejado |
| --- | --- | --- | --- | --- | --- | --- | --- | --- | --- | --- | --- | --- | --- | --- | --- | --- | --- | --- |
| 157 | 1.6 | **Implantação do Modelo** |  | 65d | 2023-02-14 | 2023-05-15 |  | 2023-02-14 | 2023-05-15 | 65d | 2023-02-14 | 2023-05-15 | 0d |  | 160h | 4,813,600 | 4,813,600 | 0% |
| 158 | 1.6.1 | **Implantação do Piloto** |  | 30d | 2023-02-14 | 2023-03-27 |  | 2023-02-14 | 2023-03-27 | 30d | 2023-02-14 | 2023-03-27 | 0d |  |  | 2,400,000 | 2,400,000 | 0% |
| 159 | 1.6.1.1 | Definir Piloto |  | 5d | 2023-02-14 | 2023-02-20 | 151 | 2023-02-14 | 2023-02-20 | 5d | 2023-02-14 | 2023-02-20 | 0d | Consultoria CM |  | 800,000 | 800,000 | 0% |
| 160 | 1.6.1.2 | Implantar Piloto |  | 20d | 2023-02-21 | 2023-03-20 | 159 | 2023-02-21 | 2023-03-20 | 20d | 2023-02-21 | 2023-03-20 | 0d | Consultoria CM |  | 800,000 | 800,000 | 0% |
| 161 | 1.6.1.3 | Emitir relatório de implantação |  | 5d | 2023-03-21 | 2023-03-27 | 160 | 2023-03-21 | 2023-03-27 | 5d | 2023-03-21 | 2023-03-27 | 0d | Consultoria CM |  | 800,000 | 800,000 | 0% |
| 162 | 1.6.2 | **Avaliação do Piloto** |  | 10d | 2023-03-28 | 2023-04-10 |  | 2023-03-28 | 2023-04-10 | 10d | 2023-03-28 | 2023-04-10 | 0d |  | 160h | 13,600 | 13,600 | 0% |
| 163 | 1.6.2.1 | Avaliar resultados |  | 5d | 2023-03-28 | 2023-04-03 | 161 | 2023-03-28 | 2023-04-03 | 5d | 2023-03-28 | 2023-04-03 | 0d | Coordenador; GP | 80h | 6,800 | 6,800 | 0% |
| 164 | 1.6.2.2 | Definir ações corretivas |  | 5d | 2023-04-04 | 2023-04-10 | 163 | 2023-04-04 | 2023-04-10 | 5d | 2023-04-04 | 2023-04-10 | 0d | Coordenador; GP | 80h | 6,800 | 6,800 | 0% |
| 165 | 1.6.3 | **Implantação do modelo completo – Roll out** |  | 25d | 2023-04-11 | 2023-05-15 |  | 2023-04-11 | 2023-05-15 | 25d | 2023-04-11 | 2023-05-15 | 0d |  |  | 2,400,000 | 2,400,000 | 0% |
| 166 | 1.6.3.1 | Preparar implantação completa |  | 5d | 2023-04-11 | 2023-04-17 | 164 | 2023-04-11 | 2023-04-17 | 5d | 2023-04-11 | 2023-04-17 | 0d | Consultoria CM |  | 800,000 | 800,000 | 0% |
| 167 | 1.6.3.2 | Realizar implantação completa |  | 15d | 2023-04-18 | 2023-05-08 | 166 | 2023-04-18 | 2023-05-08 | 15d | 2023-04-18 | 2023-05-08 | 0d | Consultoria CM |  | 800,000 | 800,000 | 0% |
| 168 | 1.6.3.3 | Emitir relatório de implantação completa |  | 5d | 2023-05-09 | 2023-05-15 | 167 | 2023-05-09 | 2023-05-15 | 5d | 2023-05-09 | 2023-05-15 | 0d | Consultoria CM |  | 800,000 | 800,000 | 0% |
| 169 | 1.6.4 | Implantação Finalizada | milestone | 0d | 2023-05-15 | 2023-05-15 | 168 | 2023-05-15 | 2023-05-15 | 0d | 2023-05-15 | 2023-05-15 | 0d |  |  |  |  | 0% |
