# Gestão de Competências - Recursos

Schedule from MS Project, 2022-04-11 to 2022-06-01.

## Calendars

- Standard: Mon-Fri 08:00-12:00, 13:00-17:00; Sat-Sun off.

## Resources

| Resource |
| --- |
| GP |
| Cliente |
| Patrocinador |
| Coordenador |
| Suprimentos |
| Equipe DC |
| FSW |
| Suporte |
| Equipe CM |
| Consultoria CM |
| Executivo |

## Schedule

| ID | WBS | Task | Type | Duration | Start | Finish | Predecessors | Total slack | Free slack | Constraint | Resources | Work |
| --- | --- | --- | --- | --- | --- | --- | --- | --- | --- | --- | --- | --- |
| 1 | 1 | **Modelo de Gestão por Competências** |  | 37d? | 2022-04-11 | 2022-06-01 |  | 0d |  |  |  | 440h |
| 2 | 1.1 | TAP Assinado | milestone | 0d | 2022-04-11 | 2022-04-11 |  | 0d |  |  |  |  |
| 3 | 1.2 | **Gerenciamento** |  | 37d? | 2022-04-11 | 2022-06-01 |  | 0d |  |  |  | 64h |
| 4 | 1.2.1 | **Planejamento** |  | 3d? | 2022-04-11 | 2022-04-14 |  | 0d |  |  |  | 32h |
| 5 | 1.2.1.1 | Elaborar plano de projeto |  | 1d? | 2022-04-11 | 2022-04-12 | 2 | 0d |  |  | GP | 8h |
| 6 | 1.2.1.2 | Homologar plano de projeto |  | 1d? | 2022-04-12 | 2022-04-13 | 5 | 0d |  |  | Cliente; Patrocinador | 16h |
| 7 | 1.2.1.3 | Ajustar plano de projeto |  | 1d? | 2022-04-13 | 2022-04-14 | 6 | 0d |  |  | GP | 8h |
| 8 | 1.2.1.4 | Plano de projeto elaborado | milestone | 0d | 2022-04-14 | 2022-04-14 | 7FF | 0d |  |  |  |  |
| 9 | 1.2.2 | **Monitoramento e Controle** |  | 11.12d | 2022-04-18 | 2022-05-03 | 8 | 20.88d |  |  |  |  |
| 10 | 1.2.2.1 | **Realizar medição do projeto** |  | 11d | 2022-04-18 | 2022-05-03 |  | 21d |  |  |  |  |
| 11 | 1.2.2.1.1 | Realizar medição do projeto 1 |  | 3.33d | 2022-04-18 | 2022-04-21 |  | 28.67d |  | start no earlier than 2022-04-18 |  |  |
| 12 | 1.2.2.1.2 | Realizar medição do projeto 2 |  | 1d | 2022-04-25 | 2022-04-26 |  | 26d |  | start no earlier than 2022-04-25 |  |  |
| 13 | 1.2.2.1.3 | Realizar medição do projeto 3 |  | 1d | 2022-05-02 | 2022-05-03 |  | 21d |  | start no earlier than 2022-05-02 |  |  |
| 14 | 1.2.2.2 | **Realizar reunião de status report executivo** |  | 10.12d | 2022-04-19 | 2022-05-03 |  | 20.88d |  |  |  |  |
| 15 | 1.2.2.2.1 | Realizar reunião de status report executivo 1 |  | 1h | 2022-04-19 | 2022-04-19 |  | 30.88d |  | start no earlier than 2022-04-19 |  |  |
| 16 | 1.2.2.2.2 | Realizar reunião de status report executivo 2 |  | 1h | 2022-04-26 | 2022-04-26 |  | 25.88d |  | start no earlier than 2022-04-26 |  |  |
| 17 | 1.2.2.2.3 | Realizar reunião de status report executivo 3 |  | 1h | 2022-05-03 | 2022-05-03 |  | 20.88d |  | start no earlier than 2022-05-03 |  |  |
| 18 | 1.2.3 | **Encerramento** |  | 4d? | 2022-05-26 | 2022-06-01 |  | 0d |  |  |  | 32h |
| 19 | 1.2.3.1 | Obter aceite final |  | 1d? | 2022-05-26 | 2022-05-27 | 84 | 0d |  |  | Coordenador | 8h |
| 20 | 1.2.3.2 | Preparar termo de encerramento |  | 1d? | 2022-05-27 | 2022-05-30 | 19 | 0d |  |  | GP | 8h |
| 21 | 1.2.3.3 | Fechar lições aprendidas |  | 1d? | 2022-05-30 | 2022-05-31 | 20 | 0d |  |  | Coordenador | 8h |
| 22 | 1.2.3.4 | Dar baixa no sistema DCVMO |  | 1d? | 2022-05-31 | 2022-06-01 | 21 | 0d |  |  | Executivo | 8h |
| 23 | 1.2.3.5 | Projeto Encerrado | milestone | 0d | 2022-06-01 | 2022-06-01 | 22 | 0d |  |  |  |  |
| 24 | 1.3 | **Modelo** |  | 9d? | 2022-04-14 | 2022-04-27 |  | 25d |  |  |  | 88h |
| 25 | 1.3.1 | **Contratação da Consultoria** |  | 5d? | 2022-04-14 | 2022-04-21 |  | 25d |  |  |  | 56h |
| 26 | 1.3.1.1 | Divulgar RFP |  | 1d? | 2022-04-14 | 2022-04-15 | 8 | 25d | 0d |  | Suprimentos | 8h |
| 27 | 1.3.1.2 | Receber propostas |  | 1d? | 2022-04-15 | 2022-04-18 | 26 | 25d | 0d |  | Suprimentos | 8h |
| 28 | 1.3.1.3 | Avaliar propostas |  | 1d? | 2022-04-18 | 2022-04-19 | 27 | 25d | 0d |  | Suprimentos; GP | 16h |
| 29 | 1.3.1.4 | Selecionar fornecedor |  | 1d? | 2022-04-19 | 2022-04-20 | 28 | 25d | 0d |  | Executivo | 8h |
| 30 | 1.3.1.5 | Assinar contrato |  | 1d? | 2022-04-20 | 2022-04-21 | 29 | 25d | 0d |  | Consultoria CM; Patrocinador | 16h |
| 31 | 1.3.1.6 | Fornecedor Contratado | milestone | 0d | 2022-04-21 | 2022-04-21 | 30 | 25d | 0d |  |  |  |

| ID | WBS | Task | Duration | Start | Finish | Predecessors | Total slack | Free slack | Resources | Work |
| --- | --- | --- | --- | --- | --- | --- | --- | --- | --- | --- |
| 32 | 1.3.2 | **Levantamento de Requisitos** | 4d? | 2022-04-21 | 2022-04-27 |  | 25d |  |  | 32h |
| 33 | 1.3.2.1 | Definir stakeholders | 1d? | 2022-04-21 | 2022-04-22 | 31 | 25d | 0d | GP | 8h |
| 34 | 1.3.2.2 | Planejar agenda de levantamento | 1d? | 2022-04-22 | 2022-04-25 | 33 | 25d | 0d | Coordenador | 8h |
| 35 | 1.3.2.3 | Levantar requisitos | 1d? | 2022-04-25 | 2022-04-26 | 34 | 25d | 0d | Equipe DC | 8h |
| 36 | 1.3.2.4 | Consolidar requisitos | 1d? | 2022-04-26 | 2022-04-27 | 35 | 25d |  | Equipe DC | 8h |
| 37 | 1.4 | **Sistema Informatizado** | 14d? | 2022-04-14 | 2022-05-04 |  | 0d |  |  | 112h |
| 38 | 1.4.1 | **Contratação da FSW** | 6d? | 2022-04-14 | 2022-04-22 |  | 0d |  |  | 56h |
| 39 | 1.4.1.1 | Divulgar RFP FSW | 1d? | 2022-04-14 | 2022-04-15 | 8 | 0d |  | Suprimentos | 8h |
| 40 | 1.4.1.2 | Receber propostas FSW | 1d? | 2022-04-15 | 2022-04-18 | 39 | 0d |  | Suprimentos | 8h |
| 41 | 1.4.1.3 | Avaliar propostas FSW | 1d? | 2022-04-18 | 2022-04-19 | 40 | 0d |  | Suprimentos; GP | 16h |
| 42 | 1.4.1.4 | Selecionar fornecedor FSW | 1d? | 2022-04-19 | 2022-04-20 | 41 | 0d |  | Executivo | 8h |
| 43 | 1.4.1.5 | Assinar contrato FSW | 1d? | 2022-04-20 | 2022-04-21 | 42 | 0d |  | Consultoria CM; Patrocinador | 16h |
| 44 | 1.4.1.6 | FSW Contratada | 1d? | 2022-04-21 | 2022-04-22 | 43 | 0d |  |  |  |
| 45 | 1.4.2 | **Desenvolvimento** | 5d? | 2022-04-22 | 2022-04-29 | 44 | 0d |  |  | 24h |
| 46 | 1.4.2.1 | Desenvolver APP | 1d? | 2022-04-22 | 2022-04-25 |  | 4d |  | FSW | 8h |
| 47 | 1.4.2.2 | Fiscalizar FSW | 5d? | 2022-04-22 | 2022-04-29 |  | 0d |  | Coordenador [50%]; GP [20%] | 16h |
| 48 | 1.4.3 | **Instalação** | 3d? | 2022-04-29 | 2022-05-04 |  | 0d |  |  | 32h |
| 49 | 1.4.3.1 | Instalar em produção | 1d? | 2022-04-29 | 2022-05-02 | 45 | 0d |  | Equipe DC | 8h |
| 50 | 1.4.3.2 | Fazer testes em produção | 1d? | 2022-05-02 | 2022-05-03 | 49 | 0d |  | Equipe DC | 8h |
| 51 | 1.4.3.3 | Ajustar instalação | 1d? | 2022-05-02 | 2022-05-03 | 50FF | 0d |  | Equipe DC | 8h |
| 52 | 1.4.3.4 | Emitir aceite de produção | 1d? | 2022-05-03 | 2022-05-04 | 51 | 0d |  | Suporte | 8h |
| 53 | 1.5 | **Change Management** | 16d? | 2022-05-04 | 2022-05-26 |  | 0d |  |  | 96h |
| 54 | 1.5.1 | **Definição das Ações** | 2d? | 2022-05-04 | 2022-05-06 |  | 0d |  |  | 24h |
| 55 | 1.5.1.1 | Plenejar ações de CM | 1d? | 2022-05-04 | 2022-05-05 | 52 | 0d |  | Consultoria CM | 8h |
| 56 | 1.5.1.2 | Aprovar plano de ações de CM | 1d? | 2022-05-05 | 2022-05-06 | 55 | 0d |  | Consultoria CM | 8h |
| 57 | 1.5.1.3 | Ajustar plano de ações de CM | 1d? | 2022-05-05 | 2022-05-06 | 56FF | 0d |  | Consultoria CM | 8h |

| ID | WBS | Task | Type | Duration | Start | Finish | Predecessors | Total slack | Free slack | Resources | Work |
| --- | --- | --- | --- | --- | --- | --- | --- | --- | --- | --- | --- |
| 58 | 1.5.2 | **Realização das Ações** |  | 3d? | 2022-05-06 | 2022-05-11 |  | 0d |  |  | 24h |
| 59 | 1.5.2.1 | Realizar ações de CM |  | 1d? | 2022-05-06 | 2022-05-09 | 57 | 0d |  | Consultoria CM | 8h |
| 60 | 1.5.2.2 | Gerar relatório das ações de CM |  | 1d? | 2022-05-09 | 2022-05-10 | 59 | 0d |  | Consultoria CM | 8h |
| 61 | 1.5.2.3 | Divulgar ações realizadas |  | 1d? | 2022-05-10 | 2022-05-11 | 60 | 0d |  | Consultoria CM | 8h |
| 62 | 1.5.3 | **Endomarketing** |  | 3d? | 2022-05-11 | 2022-05-16 |  | 0d |  |  | 24h |
| 63 | 1.5.3.1 | Plenejar ações de ENDOMKT |  | 1d? | 2022-05-11 | 2022-05-12 | 61 | 0d |  | Consultoria CM | 8h |
| 64 | 1.5.3.2 | Aprovar ações de ENDOMKT |  | 1d? | 2022-05-12 | 2022-05-13 | 63 | 0d |  | Consultoria CM | 8h |
| 65 | 1.5.3.3 | Ajustar ações de ENDOMKT |  | 1d? | 2022-05-12 | 2022-05-13 | 64FF | 0d |  | Consultoria CM | 8h |
| 66 | 1.5.3.4 | Realizar divulgação |  | 1d? | 2022-05-13 | 2022-05-16 | 65 | 0d |  |  |  |
| 67 | 1.5.4 | **Capacitação no Novo Modelo** |  | 3d? | 2022-05-23 | 2022-05-26 |  | 4d |  |  | 24h |
| 68 | 1.5.4.1 | Selecionar público |  | 1d? | 2022-05-23 | 2022-05-24 | 79 | 4d | 0d | Consultoria CM | 8h |
| 69 | 1.5.4.2 | Treinar público |  | 1d? | 2022-05-24 | 2022-05-25 | 68 | 4d | 0d | Consultoria CM | 8h |
| 70 | 1.5.4.3 | Emitir relatório de capacitação |  | 1d? | 2022-05-25 | 2022-05-26 | 69 | 4d | 0d | Consultoria CM | 8h |
| 71 | 1.5.5 | CM Finalizado | milestone | 0d | 2022-05-26 | 2022-05-26 | 70 | 4d |  |  |  |
| 72 | 1.6 | **Implantação do Modelo** |  | 8d? | 2022-05-16 | 2022-05-26 |  | 0d |  |  | 80h |
| 73 | 1.6.1 | **Implantação do Piloto** |  | 3d? | 2022-05-16 | 2022-05-19 |  | 0d |  |  | 24h |
| 74 | 1.6.1.1 | Definir Piloto |  | 1d? | 2022-05-16 | 2022-05-17 | 66 | 0d |  | Consultoria CM | 8h |
| 75 | 1.6.1.2 | Implantar Piloto |  | 1d? | 2022-05-17 | 2022-05-18 | 74 | 0d |  | Consultoria CM | 8h |
| 76 | 1.6.1.3 | Emitir relatório de implantação |  | 1d? | 2022-05-18 | 2022-05-19 | 75 | 0d |  | Consultoria CM | 8h |
| 77 | 1.6.2 | **Avaliação do Piloto** |  | 2d? | 2022-05-19 | 2022-05-23 |  | 0d |  |  | 32h |
| 78 | 1.6.2.1 | Avaliar resultados |  | 1d? | 2022-05-19 | 2022-05-20 | 76 | 0d |  | Coordenador; GP | 16h |
| 79 | 1.6.2.2 | Definir ações corretivas |  | 1d? | 2022-05-20 | 2022-05-23 | 78 | 0d |  | Coordenador; GP | 16h |
| 80 | 1.6.3 | **Implantação do modelo completo – Roll out** |  | 3d? | 2022-05-23 | 2022-05-26 |  | 0d |  |  | 24h |
| 81 | 1.6.3.1 | Preparar implantação completa |  | 1d? | 2022-05-23 | 2022-05-24 | 79 | 0d |  | Consultoria CM | 8h |
| 82 | 1.6.3.2 | Realizar implantação completa |  | 1d? | 2022-05-24 | 2022-05-25 | 81 | 0d |  | Consultoria CM | 8h |
| 83 | 1.6.3.3 | Emitir relatório de implantação completa |  | 1d? | 2022-05-25 | 2022-05-26 | 82 | 0d |  | Consultoria CM | 8h |
| 84 | 1.6.4 | Implantação Finalizada | milestone | 0d | 2022-05-26 | 2022-05-26 | 83 | 0d |  |  |  |
